# wind_park1

Schedule from MS Project, 2014-10-01 to 2018-05-08.
TEI

## Calendars

- Standard: Mon-Fri 08:00-12:00, 13:00-17:00; Sat-Sun off.

## Schedule

| ID | Task | Type | Duration | Start | Finish | Predecessors | Total slack | Free slack | Constraint |
| --- | --- | --- | --- | --- | --- | --- | --- | --- | --- |
| 1 | Μετρήσεις αιολικού δυναμικού |  | 270d? | 2014-10-01 | 2015-10-13 |  | 5d | 0d | start no earlier than 2014-10-01 |
| 2 | Αρχική τεχνικοοικονομική μελέτη |  | 30d | 2015-10-14 | 2015-11-24 | 1 | 5d | 0d |  |
| 3 | Λήψη απόφασης για την επένδυση | milestone | 1d | 2015-11-25 | 2015-11-25 | 2 | 555d | 0d |  |
| 4 | Άδεια λειτουργίας |  | 54d | 2015-11-26 | 2016-02-09 | 3 | 584d | 0d |  |
| 5 | Ανάπτυξη γης και προετοιμασία χώρου εγκατάστασης |  | 84d | 2015-11-26 | 2016-03-22 | 3 | 555d |  |  |
| 6 | Οικονομική ανάλυση του έργου |  | 84d | 2015-11-25 | 2016-03-21 | 2 | 5d | 0d |  |
| 7 | Σύνδεση με το δίκτυο |  | 84d | 2016-03-22 | 2016-07-15 | 6 | 5d | 0d |  |
| 8 | Άδεια εγκατάστασης | milestone | 1d | 2016-02-10 | 2016-02-10 | 4 | 584d |  | finish no earlier than 2006-06-04 |
| 9 | Λεπτομερής σχεδιασμός ηλεκτρολογικών και έργων ΠΜ |  | 85d | 2016-07-18 | 2016-11-11 | 7 | 5d | 0d |  |
| 10 | Διαγωνισμός - αξιολόγηση προσφορών |  | 84d | 2016-11-14 | 2017-03-09 | 9 | 5d | 0d |  |
| 11 | Διαδιασία υπογραφής σύμβασης |  | 54d | 2017-03-10 | 2017-05-24 | 10 | 5d | 0d |  |
| 12 | Κατασκευή αιολικού πάρκου |  | 162d | 2017-05-25 | 2018-01-05 | 11 | 5d | 0d |  |
| 13 | Ξεκίνημα του εργοστασίου |  | 54d | 2018-01-08 | 2018-03-22 | 12 | 5d | 0d |  |
| 14 | Δοκιμαστική λειτουργία |  | 27d | 2018-03-23 | 2018-04-30 | 13 | 5d | 0d |  |
| 15 | Έναρξη πλήρους λειτουργίας | milestone | 1d? | 2018-05-01 | 2018-05-01 | 14 | 5d |  |  |
| 16 | Επικοινωνία με τον ιδιοκτήτη του έργου |  | 940d | 2014-10-01 | 2018-05-08 |  | 0d |  | start no earlier than 2014-10-01 |
| 17 | Επικοινωνία με την τοπική κοινωνία και τις τοπικές αρχές |  | 940d | 2014-10-01 | 2018-05-08 |  | 0d |  | start no earlier than 2014-10-01 |
